# Master Schedule

Schedule from MS Project, 2022-03-01 to 2023-03-01, costs in $.

## Calendars

- Standard: Mon-Fri 08:00-12:00, 13:00-17:00; Sat-Sun off.

## Schedule

| ID | WBS | Task | Duration | Start | Finish | Predecessors | Total slack | Free slack | Constraint | Cost |
| --- | --- | --- | --- | --- | --- | --- | --- | --- | --- | --- |
| 1 | 1 | **Master plan** | 327d | 2022-03-01 | 2023-03-01 |  | 0d |  |  | 95 |
| 2 | 1.1 | **PERMIT** | 327d | 2022-03-01 | 2023-03-01 |  | 0d |  |  | 5 |
| 3 | 1.1.1 | **Construction** | 155d | 2022-03-01 | 2022-08-02 |  | 7d |  |  | 2.25 |
| 4 | 1.1.1.1 | COP/ESA | 60d | 2022-03-01 | 2022-04-29 |  | 7d | 0d | start no earlier than 2022-03-01 | 0.75 |
| 5 | 1.1.1.2 | รง 4 | 110d | 2022-04-15 | 2022-08-02 | 4FS-15d | 7d | 0d |  | 0.75 |
| 6 | 1.1.1.3 | อ 1 | 14d | 2022-03-22 | 2022-04-04 | 14SS+7d | 169d | 39d |  | 0.75 |
| 7 | 1.1.2 | **OPERATION** | 157d | 2022-08-18 | 2023-03-01 |  | 0d |  |  | 2.75 |
| 8 | 1.1.2.1 | พค 2 | 90d | 2022-09-24 | 2023-01-18 | 68FS-20d | 0d |  |  | 0.75 |
| 9 | 1.1.2.2 | อ 6 | 45d | 2022-10-24 | 2022-12-23 | 68FS+7d | 18d |  |  | 0.5 |
| 10 | 1.1.2.3 | ใบอนุญาตผลิตไฟฟ้า | 90d | 2022-08-18 | 2022-11-28 | 5FS+15d | 37d |  |  | 0.5 |
| 11 | 1.1.2.4 | PEA : Grid Connection permit | 120d | 2022-08-18 | 2023-01-09 | 5FS+15d | 7d | 0d |  | 0.5 |
| 12 | 1.1.2.5 | แจ้งเริ่มประกอบกิจการ | 30d | 2023-01-19 | 2023-03-01 | 9, 8, 10, 11 | 0d |  |  | 0.5 |
| 13 | 1.2 | **ENGINEERING** | 105d | 2022-03-15 | 2022-06-27 |  | 34d |  |  | 10 |
| 14 | 1.2.1 | Conceptual Design | 30d | 2022-03-15 | 2022-04-13 |  | 34d | 0d | start no earlier than 2022-03-15 |  |
| 15 | 1.2.2 | Shop / Detail Design | 75d | 2022-04-14 | 2022-06-27 | 14 | 34d | 0d |  | 10 |
| 16 | 1.3 | **PROCUREMENT** | 115d | 2022-05-20 | 2022-09-12 |  | 132d |  |  | 40 |
| 17 | 1.3.1 | **Equipment** | 115d | 2022-05-20 | 2022-09-12 |  | 132d |  |  | 23.5 |
| 18 | 1.3.1.1 | PV Module | 60d | 2022-06-23 | 2022-08-22 | 84SF-5d | 153d |  |  | 5 |
| 19 | 1.3.1.2 | Inverter | 60d | 2022-05-30 | 2022-07-29 | 86SF-5d | 177d |  | start no earlier than 2022-05-18 | 2 |
| 20 | 1.3.1.3 | Smartlogger | 60d | 2022-06-08 | 2022-08-07 | 87SF-5d | 168d |  |  | 1 |
| 21 | 1.3.1.4 | AC Panel 1 | 60d | 2022-06-09 | 2022-08-08 | 88SF-5d | 167d |  |  | 2 |
| 22 | 1.3.1.5 | AC Panel 2 | 60d | 2022-06-09 | 2022-08-08 | 88SF-5d | 167d |  |  | 2 |
| 23 | 1.3.1.6 | Load Panel for Module Cleaning | 30d | 2022-07-09 | 2022-08-08 | 88SF-5d | 167d |  |  |  |
| 24 | 1.3.1.7 | Transformer 3.2MVA | 90d | 2022-05-20 | 2022-08-18 | 89SF-5d | 157d |  | start no earlier than 2022-05-20 | 2 |
| 25 | 1.3.1.8 | 22kV RMU | 60d | 2022-06-22 | 2022-08-21 | 90SF-5d | 154d | 0d |  | 2 |
| 26 | 1.3.1.9 | CT PT | 60d | 2022-07-14 | 2022-09-12 | 91SF-5d | 132d |  |  | 0.5 |
| 27 | 1.3.1.10 | Protection Relay | 60d | 2022-07-14 | 2022-09-12 | 92SF-5d | 132d |  |  | 0.5 |
| 28 | 1.3.1.11 | PQ meter | 60d | 2022-07-14 | 2022-09-12 | 93SF-5d | 132d |  |  | 0.5 |
| 29 | 1.3.1.12 | MccB 400AT | 30d | 2022-08-01 | 2022-08-31 | 94SF-5d | 144d |  |  | 1 |
| 30 | 1.3.1.13 | Pyranometer | 60d | 2022-06-05 | 2022-08-04 | 96SF-5d | 171d |  |  | 1 |
| 31 | 1.3.1.14 | Ambient Temp. | 30d | 2022-07-05 | 2022-08-04 | 96SF-5d | 171d |  |  | 1 |
| 32 | 1.3.1.15 | Module Temp. | 30d | 2022-07-05 | 2022-08-04 | 96SF-5d | 171d |  |  | 1 |
| 33 | 1.3.1.16 | Wind sensor | 30d | 2022-07-05 | 2022-08-04 | 96SF-5d | 171d |  |  | 1 |
| 34 | 1.3.1.17 | Mini PC | 30d | 2022-07-15 | 2022-08-14 | 97SF-5d | 161d |  |  | 0.5 |
| 35 | 1.3.1.18 | Router 4G/Hub switch | 30d | 2022-07-15 | 2022-08-14 | 97SF-5d | 161d |  |  |  |
| 36 | 1.3.1.19 | Revenue Meter | 60d | 2022-06-22 | 2022-08-21 | 25FF | 154d |  |  | 0.5 |

| ID | WBS | Task | Duration | Start | Finish | Predecessors | Total slack | Cost |
| --- | --- | --- | --- | --- | --- | --- | --- | --- |
| 37 | 1.3.2 | **CABLE** | 83d | 2022-06-14 | 2022-09-05 |  | 139d | 8 |
| 38 | 1.3.2.1 | **AC Cable** | 83d | 2022-06-14 | 2022-09-05 |  | 139d | 5 |
| 39 | 1.3.2.1.1 | 4C-95 sq.mm. 0.6/1 kV CV cable | 45d | 2022-06-14 | 2022-07-29 | 107SF-5d | 177d | 1 |
| 40 | 1.3.2.1.2 | 1C-240 sq.mm. 0.6/1 kV CV cable | 45d | 2022-07-07 | 2022-08-21 | 108SF-5d | 154d | 1 |
| 41 | 1.3.2.1.3 | 1C-25 sq.mm. THW cable | 45d | 2022-06-14 | 2022-07-29 | 109SF-5d | 177d | 1 |
| 42 | 1.3.2.1.4 | 1C-120 sq.mm. 12/20(24) kV XLPE cable | 45d | 2022-07-22 | 2022-09-05 | 110SF-5d | 139d | 1 |
| 43 | 1.3.2.1.5 | 1C-120 sq.mm. SAC cable | 45d | 2022-07-20 | 2022-09-03 | 111SF-5d | 141d | 1 |
| 44 | 1.3.2.2 | DC Cable | 45d | 2022-06-28 | 2022-08-12 | 112SF-5d | 163d | 2 |
| 45 | 1.3.2.3 | Communication Cable | 45d | 2022-07-18 | 2022-09-01 | 113SF-5d | 143d | 0.5 |
| 46 | 1.3.2.4 | FO Cable | 45d | 2022-07-13 | 2022-08-27 | 114SF-5d | 148d | 0.5 |
| 47 | 1.3.2.5 | Control Cable | 45d | 2022-07-18 | 2022-09-01 | 115SF-5d | 143d |  |
| 48 | 1.3.3 | **ROUTE LINE** | 78d | 2022-06-09 | 2022-08-26 |  | 149d | 4 |
| 49 | 1.3.3.1 | 22kV OH Line | 45d | 2022-07-08 | 2022-08-22 | 103SF-7d | 153d | 1 |
| 50 | 1.3.3.2 | 22kV Drop out Fuse | 45d | 2022-07-08 | 2022-08-22 | 103SF-7d | 153d | 1 |
| 51 | 1.3.3.3 | 22kV Lightning Arrester | 45d | 2022-07-08 | 2022-08-22 | 103SF-7d | 153d | 1 |
| 52 | 1.3.3.4 | Cable Tray | 30d | 2022-06-09 | 2022-07-09 | 99SF-5d | 197d | 0.5 |
| 53 | 1.3.3.5 | Conduit | 20d | 2022-07-03 | 2022-07-23 | 100SF-5d | 183d |  |
| 54 | 1.3.3.6 | HDPE Conduit | 20d | 2022-08-06 | 2022-08-26 | 102SF-5d | 149d | 0.5 |
| 55 | 1.3.3.7 | MC4 | 15d | 2022-07-28 | 2022-08-12 | 112SF-5d | 163d |  |
| 56 | 1.3.4 | **STRUCTURE** | 67d | 2022-05-29 | 2022-08-04 |  | 171d | 4.5 |
| 57 | 1.3.4.1 | Mounting Structure | 30d | 2022-06-21 | 2022-07-21 | 78SF-5d | 185d | 1 |
| 58 | 1.3.4.2 | Sling Gurad | 15d | 2022-06-01 | 2022-06-16 | 76SF-5d | 220d | 1 |
| 59 | 1.3.4.3 | Walkway & Life line | 30d | 2022-05-31 | 2022-06-30 | 77SF-5d | 206d | 1 |
| 60 | 1.3.4.4 | Inverter Station | 20d | 2022-05-29 | 2022-06-18 | 79SF-5d | 218d | 1 |
| 61 | 1.3.4.5 | Ladder | 30d | 2022-07-05 | 2022-08-04 | 82SF-5d | 171d | 0.5 |
| 62 | 1.3.4.6 | Stanchion for Weather station | 30d | 2022-06-30 | 2022-07-30 | 81SF-5d | 176d |  |

| ID | WBS | Task | Duration | Start | Finish | Predecessors | Total slack | Free slack | Constraint | Cost |
| --- | --- | --- | --- | --- | --- | --- | --- | --- | --- | --- |
| 63 | 1.3.5 | **WATER SYSTEM** | 30d | 2022-07-26 | 2022-08-25 |  | 150d |  |  |  |
| 64 | 1.3.5.1 | Water Pipe | 15d | 2022-08-10 | 2022-08-25 | 65FF | 150d |  |  |  |
| 65 | 1.3.5.2 | Water pump | 30d | 2022-07-26 | 2022-08-25 | 127SF-5d | 150d | 0d |  |  |
| 66 | 1.3.5.3 | Water Tank | 15d | 2022-08-10 | 2022-08-25 | 65FF | 150d |  |  |  |
| 67 | 1.3.5.4 | Hose bibb | 7d | 2022-08-18 | 2022-08-25 | 65FF | 150d |  |  |  |
| 68 | 1.4 | **CONSTRUCTION** | 134d | 2022-06-02 | 2022-10-13 |  | 0d |  |  | 30 |
| 69 | 1.4.1 | **Preparation Phase** | 7d | 2022-06-02 | 2022-06-08 |  | 12d |  |  | 0.2 |
| 70 | 1.4.1.1 | Site Mobilization | 5d | 2022-06-02 | 2022-06-06 | 72SS-2d | 129d |  | start no earlier than 2022-03-25 | 0.1 |
| 71 | 1.4.1.2 | **Roof Check** | 5d | 2022-06-04 | 2022-06-08 |  | 10d |  |  | 0.1 |
| 72 | 1.4.1.2.1 | Scraffolding | 2d | 2022-06-04 | 2022-06-05 | 6FS+21d | 130d | 0d | start no earlier than 2022-06-04 |  |
| 73 | 1.4.1.2.2 | Roof survey | 2d | 2022-06-07 | 2022-06-08 |  | 7d |  | start no earlier than 2022-06-07 | 0.1 |
| 74 | 1.4.2 | **Installation Phase** | 115d | 2022-06-21 | 2022-10-13 |  | 0d |  |  | 29.8 |
| 75 | 1.4.2.1 | **Structure** | 64d | 2022-06-21 | 2022-08-23 |  | 0d |  |  | 2.7 |
| 76 | 1.4.2.1.1 | Guard rail | 14d | 2022-06-21 | 2022-07-04 | 73FS+5d | 0d |  | start no earlier than 2022-06-21 | 0.5 |
| 77 | 1.4.2.1.2 | Walkway | 21d | 2022-07-05 | 2022-07-25 | 76 | 0d |  |  | 0.5 |
| 78 | 1.4.2.1.3 | Mounting Structure | 25d | 2022-07-26 | 2022-08-19 | 77 | 0d |  |  | 0.5 |
| 79 | 1.4.2.1.4 | Inverter Station | 21d | 2022-06-23 | 2022-07-13 | 15FS-5d | 34d | 0d |  | 0.5 |
| 80 | 1.4.2.1.5 | RMU Foundation | 21d | 2022-07-14 | 2022-08-03 | 79 | 48d | 0d |  | 0.5 |
| 81 | 1.4.2.1.6 | Stanchion for Weather station | 5d | 2022-08-04 | 2022-08-08 | 80 | 51d | 0d |  | 0.1 |
| 82 | 1.4.2.1.7 | Ladder | 15d | 2022-08-09 | 2022-08-23 | 81 | 51d | 0d |  | 0.1 |
| 83 | 1.4.2.2 | **Equipment** | 72d | 2022-08-03 | 2022-10-13 |  | 0d |  |  | 18.1 |
| 84 | 1.4.2.2.1 | PV Module | 35d | 2022-08-27 | 2022-09-30 | 129, 5 | 0d |  |  | 5 |
| 85 | 1.4.2.2.2 | PV Wiring | 20d | 2022-09-24 | 2022-10-13 | 84FS-7d | 0d |  |  | 0.5 |
| 86 | 1.4.2.2.3 | Inverter | 10d | 2022-08-03 | 2022-08-12 | 79, 5 | 26d | 0d |  | 2 |
| 87 | 1.4.2.2.4 | Smart logger | 1d | 2022-08-12 | 2022-08-12 | 86FF | 62d | 0d |  | 0.2 |
| 88 | 1.4.2.2.5 | AC Panel | 2d | 2022-08-13 | 2022-08-14 | 79, 86, 5 | 59d | 0d |  | 2 |
| 89 | 1.4.2.2.6 | Transformer | 3d | 2022-08-23 | 2022-08-25 | 86FS+10d, 5 | 26d | 0d |  | 3 |
| 90 | 1.4.2.2.7 | RMU | 3d | 2022-08-26 | 2022-08-28 | 80, 5, 89 | 26d | 0d |  | 3 |
| 91 | 1.4.2.2.8 | CT PT | 1d | 2022-09-17 | 2022-09-17 | 92FF | 26d | 0d |  | 0.5 |
| 92 | 1.4.2.2.9 | Protection Relay | 1d | 2022-09-17 | 2022-09-17 | 90, 95FF | 26d | 0d |  | 0.5 |
| 93 | 1.4.2.2.10 | PQ meter | 1d | 2022-09-17 | 2022-09-17 | 92FF | 26d | 0d |  | 0.5 |
| 94 | 1.4.2.2.11 | MccB 400AT (Tie-in) | 1d | 2022-09-05 | 2022-09-05 | 119, 88 | 38d | 0d |  | 0.5 |
| 95 | 1.4.2.2.12 | MV Tie-in | 2d | 2022-09-16 | 2022-09-17 | 90, 89, 121 | 26d | 0d |  | 0.2 |
| 96 | 1.4.2.2.13 | Weather Station | 3d | 2022-08-09 | 2022-08-11 | 81, 5 | 54d | 0d | start no earlier than 2022-08-01 | 0.1 |
| 97 | 1.4.2.2.14 | Computer / Router / Switch hub | 2d | 2022-08-19 | 2022-08-20 | 96FS+7d | 54d | 0d |  | 0.1 |

| ID | WBS | Task | Duration | Start | Finish | Predecessors | Total slack | Free slack | Cost |
| --- | --- | --- | --- | --- | --- | --- | --- | --- | --- |
| 98 | 1.4.2.3 | **Cable Route** | 58d | 2022-07-14 | 2022-09-09 |  | 26d |  | 1.4 |
| 99 | 1.4.2.3.1 | AC Cable Tray | 14d | 2022-07-14 | 2022-07-27 | 79 | 34d | 0d | 0.3 |
| 100 | 1.4.2.3.2 | DC Cable Tray | 20d | 2022-07-28 | 2022-08-16 | 99 | 34d | 0d | 0.3 |
| 101 | 1.4.2.3.3 | MV Cable Tray | 10d | 2022-08-17 | 2022-08-26 | 100 | 34d | 0d | 0.2 |
| 102 | 1.4.2.3.4 | MV UG Route | 10d | 2022-08-31 | 2022-09-09 | 103FF+2d | 26d | 0d | 0.3 |
| 103 | 1.4.2.3.5 | OH line | 10d | 2022-08-29 | 2022-09-07 | 89, 90 | 26d | 0d | 0.3 |
| 104 | 1.4.2.3.6 | Other | 5d | 2022-08-27 | 2022-08-31 | 101 | 34d | 0d |  |
| 105 | 1.4.2.4 | **Pulling Cable** | 42d | 2022-08-03 | 2022-09-13 | 5 | 29d | 0d | 6.6 |
| 106 | 1.4.2.4.1 | **AC Cable** | 42d | 2022-08-03 | 2022-09-13 |  | 28d |  | 4.3 |
| 107 | 1.4.2.4.1.1 | 4C-95 sq.mm. 0.6/1 kV CV cable | 10d | 2022-08-03 | 2022-08-12 | 99 | 57d | 0d | 1 |
| 108 | 1.4.2.4.1.2 | 1C-240 sq.mm. 0.6/1 kV CV cable | 7d | 2022-08-26 | 2022-09-01 | 99, 89 | 38d | 0d | 1 |
| 109 | 1.4.2.4.1.3 | 1C-25 sq.mm. THW cable | 5d | 2022-08-03 | 2022-08-07 | 99 | 64d | 0d | 0.5 |
| 110 | 1.4.2.4.1.4 | 1C-120 sq.mm. 12/20(24) kV XLPE cable | 4d | 2022-09-10 | 2022-09-13 | 102, 101 | 26d | 0d | 1 |
| 111 | 1.4.2.4.1.5 | 1C-120 sq.mm. SAC cable | 5d | 2022-09-08 | 2022-09-12 | 103 | 29d | 0d | 0.8 |
| 112 | 1.4.2.4.2 | DC Cable | 14d | 2022-08-17 | 2022-08-30 | 100 | 37d | 0d | 2 |
| 113 | 1.4.2.4.3 | Communication Cable | 3d | 2022-09-06 | 2022-09-08 | 114 | 34d | 0d | 0.1 |
| 114 | 1.4.2.4.4 | FO Cable | 5d | 2022-09-01 | 2022-09-05 | 104 | 34d | 0d | 0.1 |
| 115 | 1.4.2.4.5 | Control Cable | 3d | 2022-09-06 | 2022-09-08 | 113SS | 34d | 0d | 0.1 |
| 116 | 1.4.2.5 | **Termination Cable** | 39d | 2022-08-08 | 2022-09-15 |  | 28d |  | 1 |
| 117 | 1.4.2.5.1 | **AC Cable** | 39d | 2022-08-08 | 2022-09-15 |  | 28d |  | 0.5 |
| 118 | 1.4.2.5.1.1 | 4C-95 sq.mm. 0.6/1 kV CV cable | 5d | 2022-08-13 | 2022-08-17 | 107 | 57d | 29d | 0.1 |
| 119 | 1.4.2.5.1.2 | 1C-240 sq.mm. 0.6/1 kV CV cable | 3d | 2022-09-02 | 2022-09-04 | 108 | 38d | 0d | 0.1 |
| 120 | 1.4.2.5.1.3 | 1C-25 sq.mm. THW cable | 3d | 2022-08-08 | 2022-08-10 | 109 | 64d | 36d | 0.1 |
| 121 | 1.4.2.5.1.4 | 1C-120 sq.mm. 12/20(24) kV XLPE cable | 2d | 2022-09-14 | 2022-09-15 | 110 | 26d | 0d | 0.1 |
| 122 | 1.4.2.5.1.5 | 1C-120 sq.mm. SAC cable | 2d | 2022-09-13 | 2022-09-14 | 111 | 29d | 1d | 0.1 |
| 123 | 1.4.2.5.2 | DC Cable | 7d | 2022-08-31 | 2022-09-06 | 112 | 37d | 9d | 0.5 |
| 124 | 1.4.2.5.3 | Communication Cable | 1d | 2022-09-09 | 2022-09-09 | 113 | 34d | 6d |  |
| 125 | 1.4.2.5.4 | FO Cable | 2d | 2022-09-06 | 2022-09-07 | 114 | 36d | 0d |  |
| 126 | 1.4.2.5.5 | Control Cable | 1d | 2022-09-09 | 2022-09-09 | 115 | 34d |  |  |
| 127 | 1.4.3 | Water system | 15d | 2022-08-30 | 2022-09-13 | 105FS-15d | 30d | 0d |  |

| ID | WBS | Task | Type | Duration | Start | Finish | Predecessors | Total slack | Free slack | Cost |
| --- | --- | --- | --- | --- | --- | --- | --- | --- | --- | --- |
| 128 | 1.5 | **Inspection, Test and Commissioning** |  | 68d | 2022-08-20 | 2022-10-31 |  | 0d |  | 5 |
| 129 | 1.5.1 | Torque Monting Structure |  | 7d | 2022-08-20 | 2022-08-26 | 78 | 0d |  | 1 |
| 130 | 1.5.2 | Torque PV Module |  | 7d | 2022-10-01 | 2022-10-07 | 84 | 21d | 6d | 1 |
| 131 | 1.5.3 | I-V Test |  | 10d | 2022-10-14 | 2022-10-26 | 130, 85 | 15d | 0d | 0.5 |
| 132 | 1.5.4 | Continuity |  | 5d | 2022-09-16 | 2022-09-20 | 118, 119, 120, 121, 122, 123, 124 | 36d | 0d | 0.2 |
| 133 | 1.5.5 | Insulation test |  | 5d | 2022-09-21 | 2022-09-25 | 132 | 36d | 0d | 0.5 |
| 134 | 1.5.6 | Hi-pot test |  | 2d | 2022-09-26 | 2022-09-27 | 133 | 41d | 26d | 0.2 |
| 135 | 1.5.7 | Torque check at Cable terminate point |  | 7d | 2022-09-26 | 2022-10-02 | 133 | 36d | 21d | 0.1 |
| 136 | 1.5.8 | CT PT loop check |  | 3d | 2022-09-18 | 2022-09-20 | 91 | 51d |  | 0.2 |
| 137 | 1.5.9 | FO Cable test |  | 2d | 2022-09-08 | 2022-09-09 | 125 | 49d | 0d |  |
| 138 | 1.5.10 | Protection Relay Test |  | 1d | 2022-09-25 | 2022-09-25 | 92FS+7d | 43d | 28d | 0.2 |
| 139 | 1.5.11 | Transformer test |  | 3d | 2022-09-02 | 2022-09-04 | 89FS+7d | 64d | 49d | 0.3 |
| 140 | 1.5.12 | RMU Test |  | 3d | 2022-09-05 | 2022-09-07 | 90FS+7d | 54d | 0d | 0.3 |
| 141 | 1.5.13 | ACB Test |  | 1d | 2022-09-14 | 2022-09-14 | 88FS+7d, 140FF+7d | 54d | 39d | 0.1 |
| 142 | 1.5.14 | Communication loop check |  | 3d | 2022-09-17 | 2022-09-19 | 137FS+7d | 49d | 34d | 0.1 |
| 143 | 1.5.15 | Inverter commissioning |  | 3d | 2022-10-27 | 2022-10-31 | 131, 133, 134, 135, 141, 140, 139, 138, 137, 142 | 15d |  | 0.3 |
| 144 | 1.6 | **HANDOVER PHASE** |  | 82d | 2022-11-08 | 2023-03-01 |  | 0d |  | 5 |
| 145 | 1.6.1 | First Sync | milestone | 0d | 2023-01-09 | 2023-01-09 | 143, 11 | 14d | 0d | 1 |
| 146 | 1.6.2 | Performance Test |  | 20d | 2023-01-13 | 2023-02-09 | 145FS+3d | 14d |  | 2 |
| 147 | 1.6.3 | Site Walkdown |  | 2d | 2022-11-08 | 2022-11-09 | 128FS+5d | 15d | 0d |  |
| 148 | 1.6.4 | Punch list |  | 20d | 2022-11-10 | 2022-12-07 | 147 | 15d | 0d | 1 |
| 149 | 1.6.5 | COD | milestone | 0d | 2023-03-01 | 2023-03-01 | 145FS+7d, 11, 8, 9, 10, 12 | 0d |  | 0.5 |
| 150 | 1.6.6 | Document Handover |  | 45d | 2022-12-08 | 2023-02-08 | 148 | 15d |  | 0.5 |
